# Draft project plan v3

Schedule from MS Project, 2020-06-19 to 2021-09-24.

## Calendars

- Standard: Mon-Fri 08:00-12:00, 13:00-17:00; Sat-Sun off.

## Schedule

| ID | WBS | Task | Duration | Start | Finish | Predecessors | Total slack | Free slack | Constraint |
| --- | --- | --- | --- | --- | --- | --- | --- | --- | --- |
| 1 | 1 | **Initiation** | 21d | 2020-06-19 | 2020-07-17 |  | 0d |  |  |
| 2 | 1.1 | Kickoff meeting | 1d | 2020-06-19 | 2020-06-19 |  | 0d |  | start no earlier than 2020-06-19 |
| 3 | 1.2 | Definition of the project team | 5d | 2020-06-22 | 2020-06-26 | 2 | 15d |  |  |
| 4 | 1.3 | Project plan and schedule (first draft) | 20d | 2020-06-22 | 2020-07-17 | 2 | 0d |  |  |
| 5 | 2 | **Design** | 105d | 2020-07-20 | 2020-12-11 | 1 | 0d |  |  |
| 6 | 2.1 | Analyse the eTIR processes and data requirements | 30d | 2020-07-20 | 2020-08-28 |  | 0d |  |  |
| 7 | 2.2 | Evaluate data and triggers availability in the customs system | 25d | 2020-08-31 | 2020-10-02 | 6 | 0d |  |  |
| 8 | 2.3 | Design updates to the customs system | 30d | 2020-10-05 | 2020-11-13 | 7 | 0d |  |  |
| 9 | 2.4 | Refine project plan and schedule | 5d | 2020-11-16 | 2020-11-20 | 8 | 0d |  |  |
| 10 | 2.5 | Contingency placeholder | 15d | 2020-11-23 | 2020-12-11 | 9 | 0d |  |  |
| 11 | 3 | **Implementation** | 190d | 2020-08-31 | 2021-05-21 |  | 0d |  |  |
| 12 | 3.1 | Set up customs test environment | 10d | 2020-08-31 | 2020-09-11 | 6 | 90d | 0d |  |
| 13 | 3.2 | Establishment of a secure connection | 10d | 2020-09-14 | 2020-09-25 | 12 | 90d | 55d |  |
| 14 | 3.3 | **Messages** | 80d | 2020-12-14 | 2021-04-02 | 13, 10 | 35d |  |  |
| 15 | 3.3.1 | E9 - Advance TIR data / E10 - Advance TIR data results | 10d | 2020-12-14 | 2020-12-25 |  | 35d | 0d |  |
| 16 | 3.3.2 | E11 - Update advance TIR data / E12 - Update advance TIR data results | 10d | 2020-12-28 | 2021-01-08 | 15 | 35d | 0d |  |
| 17 | 3.3.3 | E13 - Cancel advance TIR data / E14 - Cancel advance TIR data results | 5d | 2021-01-11 | 2021-01-15 | 16 | 35d | 0d |  |
| 18 | 3.3.4 | I1 - Accept guarantee / I2 - Acceptance results | 5d | 2021-01-18 | 2021-01-22 | 17, 15 | 35d | 0d |  |
| 19 | 3.3.5 | I7 - Record declaration data / I8 - Record declaration data results | 10d | 2021-01-25 | 2021-02-05 | 18 | 35d | 0d |  |
| 20 | 3.3.6 | I9 - Start TIR operation / I10 - Start results | 5d | 2021-02-08 | 2021-02-12 | 19 | 35d | 0d |  |
| 21 | 3.3.7 | I11 - Terminate TIR operation / I12 - Termination results | 5d | 2021-02-15 | 2021-02-19 | 20 | 35d | 0d |  |
| 22 | 3.3.8 | I13 - Discharge TIR operation / I14 - Discharge results | 5d | 2021-02-22 | 2021-02-26 | 21 | 35d | 0d |  |
| 23 | 3.3.9 | I5 - Query guarantee / I6 - Query results | 10d | 2021-03-01 | 2021-03-12 | 22 | 35d | 0d |  |
| 24 | 3.3.10 | I15 - Notify Customs / I16 - Notification confirmation | 10d | 2021-03-15 | 2021-03-26 | 23 | 35d | 0d |  |
| 25 | 3.3.11 | I17 - Refusal to start TIR operation / I18 - Refusal to start TIR operation | 5d | 2021-03-29 | 2021-04-02 | 24 | 35d |  |  |

| ID | WBS | Task | Type | Duration | Start | Finish | Predecessors | Total slack | Constraint |
| --- | --- | --- | --- | --- | --- | --- | --- | --- | --- |
| 26 | 3.4 | **Implement amendments to the customs system** |  | 100d | 2020-12-14 | 2021-04-30 | 10 | 0d |  |
| 27 | 3.4.1 | Amend database |  | 20d | 2020-12-14 | 2021-01-08 |  | 0d |  |
| 28 | 3.4.2 | Amend business layer (including fallbacks) |  | 40d | 2021-01-11 | 2021-03-05 | 27 | 0d |  |
| 29 | 3.4.3 | Amend user interfaces (if required) |  | 40d | 2021-03-08 | 2021-04-30 | 28 | 0d |  |
| 30 | 3.5 | Contingency placeholder |  | 15d | 2021-05-03 | 2021-05-21 | 26 | 0d |  |
| 31 | 4 | **Conformance tests** |  | 70d | 2021-05-24 | 2021-08-27 | 11 | 0d |  |
| 32 | 4.1 | Tests individual message and troubleshooting |  | 20d | 2021-05-24 | 2021-06-18 |  | 0d |  |
| 33 | 4.2 | Test scenarios (message sequence and timing) |  | 40d | 2021-06-21 | 2021-08-13 | 32 | 0d |  |
| 34 | 4.3 | Contingency placeholder |  | 10d | 2021-08-16 | 2021-08-27 | 33 | 0d |  |
| 35 | 5 | **Closure** |  | 20d | 2021-08-30 | 2021-09-24 | 31 | 0d |  |
| 36 | 5.1 | Evaluation |  | 10d | 2021-08-30 | 2021-09-10 |  | 0d |  |
| 37 | 5.2 | Prepation of the final report |  | 10d | 2021-09-13 | 2021-09-24 | 36 | 0d |  |
| 38 | 6 | **Monitoring** |  | 251d | 2020-09-04 | 2021-08-20 | 1FS+15d | 0d |  |
| 39 | 6.1 | **Progress review** |  | 251d | 2020-09-04 | 2021-08-20 |  | 0d |  |
| 40 | 6.1.1 | Progress review 1 | manual | 1d | 2020-09-04 | 2020-09-04 |  |  | start no earlier than 2020-09-04 |
| 41 | 6.1.2 | Progress review 2 | manual | 1d | 2020-09-18 | 2020-09-18 |  |  | start no earlier than 2020-09-18 |
| 42 | 6.1.3 | Progress review 3 | manual | 1d | 2020-10-02 | 2020-10-02 |  |  | start no earlier than 2020-10-02 |
| 43 | 6.1.4 | Progress review 4 | manual | 1d | 2020-10-16 | 2020-10-16 |  |  | start no earlier than 2020-10-16 |
| 44 | 6.1.5 | Progress review 5 | manual | 1d | 2020-10-30 | 2020-10-30 |  |  | start no earlier than 2020-10-30 |
| 45 | 6.1.6 | Progress review 6 | manual | 1d | 2020-11-13 | 2020-11-13 |  |  | start no earlier than 2020-11-13 |
| 46 | 6.1.7 | Progress review 7 | manual | 1d | 2020-11-27 | 2020-11-27 |  |  | start no earlier than 2020-11-27 |
| 47 | 6.1.8 | Progress review 8 | manual | 1d | 2020-12-11 | 2020-12-11 |  |  | start no earlier than 2020-12-11 |
| 48 | 6.1.9 | Progress review 9 | manual | 1d | 2020-12-25 | 2020-12-25 |  |  | start no earlier than 2020-12-25 |
| 49 | 6.1.10 | Progress review 10 | manual | 1d | 2021-01-08 | 2021-01-08 |  |  | start no earlier than 2021-01-08 |
| 50 | 6.1.11 | Progress review 11 | manual | 1d | 2021-01-22 | 2021-01-22 |  |  | start no earlier than 2021-01-22 |
| 51 | 6.1.12 | Progress review 12 | manual | 1d | 2021-02-05 | 2021-02-05 |  |  | start no earlier than 2021-02-05 |
| 52 | 6.1.13 | Progress review 13 | manual | 1d | 2021-02-19 | 2021-02-19 |  |  | start no earlier than 2021-02-19 |
| 53 | 6.1.14 | Progress review 14 | manual | 1d | 2021-03-05 | 2021-03-05 |  |  | start no earlier than 2021-03-05 |
| 54 | 6.1.15 | Progress review 15 | manual | 1d | 2021-03-19 | 2021-03-19 |  |  | start no earlier than 2021-03-19 |
| 55 | 6.1.16 | Progress review 16 | manual | 1d | 2021-04-02 | 2021-04-02 |  |  | start no earlier than 2021-04-02 |
| 56 | 6.1.17 | Progress review 17 | manual | 1d | 2021-04-16 | 2021-04-16 |  |  | start no earlier than 2021-04-16 |
| 57 | 6.1.18 | Progress review 18 | manual | 1d | 2021-04-30 | 2021-04-30 |  |  | start no earlier than 2021-04-30 |
| 58 | 6.1.19 | Progress review 19 | manual | 1d | 2021-05-14 | 2021-05-14 |  |  | start no earlier than 2021-05-14 |
| 59 | 6.1.20 | Progress review 20 | manual | 1d | 2021-05-28 | 2021-05-28 |  |  | start no earlier than 2021-05-28 |
| 60 | 6.1.21 | Progress review 21 | manual | 1d | 2021-06-11 | 2021-06-11 |  |  | start no earlier than 2021-06-11 |
| 61 | 6.1.22 | Progress review 22 | manual | 1d | 2021-06-25 | 2021-06-25 |  |  | start no earlier than 2021-06-25 |
| 62 | 6.1.23 | Progress review 23 | manual | 1d | 2021-07-09 | 2021-07-09 |  |  | start no earlier than 2021-07-09 |
| 63 | 6.1.24 | Progress review 24 | manual | 1d | 2021-07-23 | 2021-07-23 |  |  | start no earlier than 2021-07-23 |
| 64 | 6.1.25 | Progress review 25 | manual | 1d | 2021-08-06 | 2021-08-06 |  |  | start no earlier than 2021-08-06 |
| 65 | 6.1.26 | Progress review 26 | manual | 1d | 2021-08-20 | 2021-08-20 |  |  | start no earlier than 2021-08-20 |
